# holgraphy at ATF

How a schedule from MS Project changed from version to version. A marks actual dates.

## Version 1 (saved 2006-09-22, file holography_v8.mpp)

| ID | WBS | Task | Duration | Start | Finish | Predecessors | Complete | Total float | Constraint |
| --- | --- | --- | --- | --- | --- | --- | --- | --- | --- |
| 1 | 1 | **Holography System** | 332d | 2005-11-01 A | 2007-02-13 |  | 84% | 0d |  |
| 2 |  | Develop transmitter electronics | 30w | 2005-11-01 A | 2006-05-29 A |  | 100% |  | start no earlier than 2005-11-01 |
| 3 |  | Repackage holography receiver | 32w | 2005-11-01 A | 2006-06-12 A |  | 100% |  | start no earlier than 2005-11-01 |
| 4 |  | Develop ancillary electronics (cabling, power supply, ABM, TE and 25MHz, etc.) | 30w | 2005-11-01 A | 2006-05-29 A |  | 100% |  | start no earlier than 2005-11-01 |
| 5 |  | Develop control software | 10w | 2006-03-13 A | 2006-05-19 A |  | 100% |  | start no earlier than 2006-03-12 |
| 6 |  | Modify reduction software for data format | 10d | 2006-03-13 | 2006-03-24 |  |  | 199d | start no earlier than 2006-03-12 |
| 7 |  | Ship Tx cables and spare minirack to AOC | 5d | 2006-08-07 A | 2006-08-11 A |  | 100% |  | start no earlier than 2006-08-07 |
| 9 | 1.7 | **NTC: Rx and Tx** | 57d | 2006-06-19 A | 2006-09-06 A |  | 100% |  |  |
| 10 |  | Integrate/test tx, rx at CV | 40d | 2006-06-19 A | 2006-08-11 A | 2, 3, 4, 5 | 100% |  | finish no earlier than 2006-08-11 |
| 11 |  | System test at NTC | 4d | 2006-08-25 A | 2006-08-30 A | 10 | 100% |  | finish no earlier than 2006-08-30 |
| 12 |  | Pack | 1d | 2006-08-31 A | 2006-08-31 A | 11 | 100% |  |  |
| 13 |  | Ship to AOC | 3d | 2006-09-01 A | 2006-09-06 A | 12 | 100% |  |  |
| 14 |  | Receive Tx and Rx at AOC | 0d | 2006-09-06 A | 2006-09-06 A | 13 | 100% |  |  |
| 16 | 1.8 | **AOC and ATF preparation** | 31d | 2006-08-14 A | 2006-09-26 |  | 95% | 0d |  |
| 17 |  | Inspect Tower | 1d | 2006-08-14 A | 2006-08-14 A |  | 100% |  | start no earlier than 2006-08-14 |
| 18 |  | Install Tx cables | 7d | 2006-08-28 A | 2006-09-06 A | 17, 7 | 100% |  | start no earlier than 2006-08-28 |
| 19 |  | Install Tx at ATF and verify control | 3d | 2006-09-07 A | 2006-09-11 A | 14, 18 | 100% |  |  |
| 20 |  | Prepare RF cables | 5d | 2006-08-14 A | 2006-08-18 A |  | 100% |  | finish no earlier than 2006-08-18 |
| 21 |  | Control software checkout at AOC | 5d | 2006-09-11 A | 2006-09-15 A | 14 | 100% |  | start no earlier than 2006-09-11 |
| 22 |  | Install RF and FO cables on tower | 1d | 2006-09-18 A | 2006-09-18 A | 21, 20 | 100% |  |  |
| 23 |  | Upgrade software at ATF | 3d | 2006-09-19 A | 2006-09-21 A | 22 | 100% |  |  |
| 24 |  | Prepare for mounting minirack in both antennas | 5d | 2006-08-28 A | 2006-09-01 A |  | 100% |  | start no earlier than 2006-08-28 |
| 25 |  | Antenna VA / AEC decision | 0d | 2006-09-11 A | 2006-09-11 A | 13SS | 100% |  | start no earlier than 2006-09-11 |
| 26 |  | prepare antenna for electronics | 5d | 2006-09-11 A | 2006-09-15 A | 25, 24 | 100% |  |  |
| 27 |  | Install receiver | 2d | 2006-09-25 | 2006-09-26 | 26, 21 |  | 0d | start no earlier than 2006-09-25 |
| 29 | 1.9 | **Checkout** | 8d | 2006-09-27 | 2006-10-06 | 27, 23 |  | 0d |  |
| 30 |  | Check M/C and 1st point of Tx | 1d | 2006-09-27 | 2006-09-27 |  |  | 0d |  |
| 31 |  | Ensure Tx and Rx on correct frequency, confirm adequate received power | 1d | 2006-09-28 | 2006-09-28 | 30 |  | 0d |  |
| 32 |  | Peak transmitter pointing | 1d | 2006-09-29 | 2006-09-29 | 31 |  | 0d |  |
| 33 |  | Verify receiver complex output and stability | 1d | 2006-10-02 | 2006-10-02 | 32 |  | 0d |  |
| 34 |  | Margin | 4d | 2006-10-03 | 2006-10-06 | 33 |  | 0d |  |
| 36 | 1.10 | **e2e tests of the system** | 29d | 2006-10-10 | 2006-11-17 | 29 |  | 0d |  |
| 37 |  | Verfy mount movement and synch with data | 5d | 2006-10-10 | 2006-10-16 |  |  | 0d |  |
| 38 |  | Verify writing/reading from archive | 1d | 2006-10-17 | 2006-10-17 | 37 |  | 0d |  |
| 39 |  | Perform 1st raster and create database | 2d | 2006-10-18 | 2006-10-19 | 38 |  | 0d |  |
| 40 |  | Confirm data analysis and display are working correctly | 2d | 2006-10-20 | 2006-10-23 | 39 |  | 0d |  |
| 41 |  | Produce first holo image | 5d | 2006-10-24 | 2006-10-30 | 40 |  | 0d |  |
| 42 |  | measure, adjust focus and illumination | 2d | 2006-10-31 | 2006-11-01 | 41 |  | 0d |  |
| 43 |  | Margin | 12d | 2006-11-02 | 2006-11-17 | 42 |  | 0d |  |
| 45 | 1.11 | **Science Validation** | 18d | 2006-11-20 | 2006-12-15 | 36 |  | 0d |  |
| 46 |  | a few more images | 6d | 2006-11-20 | 2006-11-29 |  |  | 0d |  |
| 47 |  | Move antenna panel to calibrate | 2d | 2006-11-30 | 2006-12-01 | 46 |  | 0d |  |
| 48 |  | Integrated User Tests | 5d | 2006-12-04 | 2006-12-08 | 47 |  | 0d |  |
| 49 |  | Test Readiness Review | 1d | 2006-12-11 | 2006-12-11 | 48 |  | 0d |  |
| 50 |  | Software rework for high-priority problems | 5d | 2006-12-11 | 2006-12-15 | 49SS |  | 0d |  |
| 52 |  | Acceptance tests | 2d | 2006-12-18 | 2006-12-19 | 45 |  | 0d |  |
| 53 |  | Margin | 5d | 2006-12-20 | 2006-12-26 | 52 |  | 0d |  |
| 54 |  | Pack up | 5d | 2006-12-27 | 2007-01-02 | 53 |  | 0d |  |
| 55 |  | ship to Chile | 20d | 2007-01-03 | 2007-01-30 | 54 |  | 0d |  |
| 56 |  | Reconfigure sofware, install, test functionality in lab. | 10d | 2007-01-31 | 2007-02-13 | 55 |  | 0d | start no earlier than 2006-08-17 |
| 57 |  | Holography system ready for installation in first antenna. | 0d | 2007-02-13 | 2007-02-13 | 56 |  | 0d |  |

## Version 2 (saved 2006-11-20, file holography_v11.mpp)

Last finish 2007-02-13 → 2007-03-22 (+37d). Complete tasks 20 → 34.

Added:

| ID | Task | Duration | Start | Finish | Predecessors | Constraint |
| --- | --- | --- | --- | --- | --- | --- |
| 42 | Investigate saturation and illumination problems | 2d | 2006-10-30 A | 2006-10-31 A | 41 | start no earlier than 2006-10-30 |
| 44 | Investigate DSP problems | 5d | 2006-11-01 | 2006-11-07 | 42 |  |
| 45 | Install / check out data reduction software at ATF | 3d | 2006-11-01 | 2006-11-03 | 42 |  |
| 46 | Order stable reference oscillators | 0d | 2006-11-09 A | 2006-11-09 A | 42 | start no earlier than 2006-11-09 |
| 47 | Deliver stable reference oscillators | 6w | 2006-11-09 | 2006-12-22 | 46 |  |
| 48 | Install new references in Rack B | 10d | 2007-01-03 | 2007-01-16 | 47 |  |
| 49 | Ship rack to ATF | 2d | 2007-01-17 | 2007-01-18 | 48 |  |
| 50 | Exchange with Rack A, update transmitter reference | 2d | 2007-01-19 | 2007-01-22 | 47FF, 49 |  |
| 51 | Continue to investigate data quality problems | 10d | 2006-11-16 | 2006-12-01 |  | must start on 2006-11-16 |
| 52 | Stress Test | 3d | 2006-11-20 | 2006-11-22 |  | must start on 2006-11-20 |
| 53 | Install / test ACS6 | 10d | 2006-12-04 | 2006-12-15 |  | must start on 2006-12-04 |
| 54 | CIPT mini-test | 4d | 2006-12-18 | 2006-12-21 | 53 |  |
| 57 | User test | 5d | 2007-01-09 | 2007-01-15 | 54 | start no earlier than 2007-01-09 |
| 62 | Plan way forward | 2d | 2007-01-23 | 2007-01-24 | 61SS |  |
| 64 | Remove Rx from antenna, replace SR | 1d | 2007-02-01 | 2007-02-01 | 63 |  |

Removed: 34 Margin; 46 a few more images; 47 Move antenna panel to calibrate; 50 Software rework for high-priority problems

Changed:

| ID | Task | Start | Finish | Duration | Complete | Total float | Predecessors | Other |
| --- | --- | --- | --- | --- | --- | --- | --- | --- |
| 1 | **Holography System** |  | 2007-02-13 → 2007-03-22 (+37d) | 332d → 352d | 84% → 81% |  |  |  |
| 16 | **AOC and ATF preparation** |  | 2006-09-26 A |  | 95% → 100% | 0d → none |  |  |
| 27 | Install receiver | 2006-09-25 A | 2006-09-26 A |  | 0% → 100% | 0d → none |  |  |
| 29 | **Checkout** | 2006-09-27 → 2006-09-29 A (+2d) | 2006-10-06 → 2006-10-11 A (+5d) |  | 0% → 100% | 0d → none |  |  |
| 30 | Check M/C and 1st point of Tx | 2006-09-27 → 2006-09-29 A (+2d) | 2006-09-27 → 2006-10-05 A (+8d) | 1d → 5d | 0% → 100% | 0d → none |  | constraint none → start no earlier than 2006-09-29 |
| 31 | Ensure Tx and Rx on correct frequency, confirm adequate received power | 2006-09-28 → 2006-10-06 A (+8d) | 2006-09-28 → 2006-10-06 A (+8d) |  | 0% → 100% | 0d → none |  |  |
| 32 | Peak transmitter pointing | 2006-09-29 → 2006-10-10 A (+11d) | 2006-09-29 → 2006-10-10 A (+11d) |  | 0% → 100% | 0d → none |  |  |
| 33 | Verify receiver complex output and stability | 2006-10-02 → 2006-10-11 A (+9d) | 2006-10-02 → 2006-10-11 A (+9d) |  | 0% → 100% | 0d → none |  |  |
| 35 | **e2e tests of the system** | 2006-10-10 → 2006-10-12 A (+2d) | 2006-11-17 → 2007-01-22 (+66d) | 29d → 64d | 0% → 17% | 0d → 43d |  |  |
| 36 | Verfy mount movement and synch with data | 2006-10-10 → 2006-10-12 A (+2d) | 2006-10-16 A | 5d → 3d | 0% → 100% | 0d → none |  |  |
| 37 | Verify writing/reading from archive | 2006-10-17 A | 2006-10-17 A |  | 0% → 100% | 0d → none |  |  |
| 38 | Perform 1st raster and create database | 2006-10-18 A | 2006-10-19 A |  | 0% → 100% | 0d → none |  |  |
| 39 | Confirm data analysis and display are working correctly | 2006-10-20 A | 2006-10-23 → 2006-10-20 A (-3d) | 2d → 1d | 0% → 100% | 0d → none |  |  |
| 40 | Produce first holo image | 2006-10-24 → 2006-10-23 A (-1d) | 2006-10-30 → 2006-10-23 A (-7d) | 5d → 1d | 0% → 100% | 0d → none |  |  |
| 41 | measure, adjust focus and illumination | 2006-10-31 → 2006-10-24 A (-7d) | 2006-11-01 → 2006-10-24 A (-8d) | 2d → 1d | 0% → 100% | 0d → none |  |  |
| 43 | Temporary remedy improve frequency/phase stability | 2006-11-02 → 2006-11-01 A (-1d) | 2006-11-17 → 2006-11-07 A (-10d) | 12d → 5d | 0% → 100% | 0d → none | 41 → 42 | was named Margin |
| 56 | **Science Validation** | 2006-11-20 → 2007-01-09 (+50d) | 2006-12-15 → 2007-01-22 (+38d) | 18d → 10d |  |  | 35 → 43 |  |
| 58 | Punchlist cleanup | 2006-12-04 → 2007-01-16 (+43d) | 2006-12-08 → 2007-01-22 (+45d) |  |  |  | Move antenna panel to calibrate → 57 | was named Integrated User Tests |
| 60 | Test Readiness Review | 2006-12-11 → 2007-01-23 (+43d) | 2006-12-11 → 2007-01-23 (+43d) |  |  | 0d → 41d | 58 → 58, 50 |  |
| 61 | Acceptance tests | 2006-12-18 → 2007-01-23 (+36d) | 2006-12-19 → 2007-01-24 (+36d) |  |  |  |  |  |
| 63 | Margin | 2006-12-20 → 2007-01-25 (+36d) | 2006-12-26 → 2007-01-31 (+36d) |  |  |  |  |  |
| 65 | Pack up | 2006-12-27 → 2007-02-02 (+37d) | 2007-01-02 → 2007-02-08 (+37d) |  |  |  | 63 → 64 |  |
| 66 | ship to Chile | 2007-01-03 → 2007-02-09 (+37d) | 2007-01-30 → 2007-03-08 (+37d) |  |  |  |  |  |
| 67 | Reconfigure sofware, install, test functionality in lab. | 2007-01-31 → 2007-03-09 (+37d) | 2007-02-13 → 2007-03-22 (+37d) |  |  |  |  |  |
| 68 | Holography system ready for installation in first antenna. | 2007-02-13 → 2007-03-22 (+37d) | 2007-02-13 → 2007-03-22 (+37d) |  |  |  |  |  |
